# طراحی و ساخت درایو کنترل دور موتور

Schedule from MS Project, 2019-07-06 to 2023-09-22, status date 2022-11-26, A marks actual dates.

## Calendars

- Standard: Mon-Sun 08:00-12:00, 13:00-17:00.

## Schedule

| ID | WBS | Task | Type | Duration | Start | Finish | Predecessors | Complete | Remaining | Baseline start | Baseline finish | Baseline duration | Total slack | شروع | پایان |
| --- | --- | --- | --- | --- | --- | --- | --- | --- | --- | --- | --- | --- | --- | --- | --- |
| 1 | 1 | **طراحی و ساخت درایو کنترل دور موتور** |  | 1540d | 2019-07-06 A | 2023-09-22 |  | 84% | 241.88d |  |  |  | 0d | 1398/04/15 | 1402/06/31 |
| 2 | 1.1 | شروع | milestone | 0d | 2019-07-06 A | 2019-07-06 A |  | 100% |  | 2019-07-06 | 2019-07-06 | 0d |  | 1398/04/15 | 1398/04/15 |
| 3 | 1.2 | **مطالعات** |  | 235d | 2019-07-06 A | 2020-02-25 A |  | 100% |  | 2019-07-06 | 2020-02-25 | 235d |  | 1398/04/15 | 1398/12/06 |
| 4 | 1.2.1 | ابلاغ قرارداد | milestone | 0d | 2019-07-06 A | 2019-07-06 A | 2 | 100% |  | 2019-07-06 | 2019-07-06 | 0d |  | 1398/04/15 | 1398/04/15 |
| 5 | 1.2.2 | تهیه برنامه زمانبندی |  | 121d | 2019-07-06 A | 2019-11-03 A | 4 | 100% |  | 2019-07-06 | 2019-11-03 | 121d |  | 1398/04/15 | 1398/08/12 |
| 6 | 1.2.3 | تایید برنامه زمانبندی |  | 3d | 2019-11-04 A | 2019-11-06 A | 5 | 100% |  | 2019-11-04 | 2019-11-06 | 3d |  | 1398/08/13 | 1398/08/15 |
| 7 | 1.2.4 | مطالعه ساختار قدرت |  | 45d | 2019-11-07 A | 2019-12-21 A | 6 | 100% |  | 2019-11-07 | 2019-12-21 | 45d |  | 1398/08/16 | 1398/09/30 |
| 8 | 1.2.5 | انتخاب ساختار قدرت |  | 2d | 2019-12-22 A | 2019-12-23 A | 7 | 100% |  | 2019-12-22 | 2019-12-23 | 2d |  | 1398/10/01 | 1398/10/02 |
| 9 | 1.2.6 | مطالعه ساختار کنترل |  | 38d | 2019-12-24 A | 2020-01-30 A | 8 | 100% |  | 2019-12-24 | 2020-01-30 | 38d |  | 1398/10/03 | 1398/11/10 |
| 10 | 1.2.7 | انتخاب ساختار کنترل |  | 14d | 2020-01-31 A | 2020-02-13 A | 9 | 100% |  | 2020-01-31 | 2020-02-13 | 14d |  | 1398/11/11 | 1398/11/24 |
| 11 | 1.2.8 | مطالعه و انتخاب سیستم خنک سازی |  | 12d | 2020-02-14 A | 2020-02-25 A | 10 | 100% |  | 2020-02-14 | 2020-02-25 | 12d |  | 1398/11/25 | 1398/12/06 |
| 12 | 1.3 | **طراحی و محاسبات** |  | 119d | 2019-12-24 A | 2020-04-20 A |  | 100% |  | 2019-12-24 | 2020-04-20 | 119d |  | 1398/10/03 | 1399/02/01 |
| 13 | 1.3.1 | طراحی اینورتر |  | 52d | 2019-12-24 A | 2020-02-13 A | 8, 7 | 100% |  | 2019-12-24 | 2020-02-13 | 52d |  | 1398/10/03 | 1398/11/24 |
| 14 | 1.3.2 | طراحی رکتیفایر |  | 38d | 2019-12-24 A | 2020-01-30 A | 8 | 100% |  | 2019-12-24 | 2020-01-30 | 38d |  | 1398/10/03 | 1398/11/10 |
| 15 | 1.3.3 | طراحی ترانسفورماتور |  | 38d | 2019-12-24 A | 2020-01-30 A | 8 | 100% |  | 2019-12-24 | 2020-01-30 | 38d |  | 1398/10/03 | 1398/11/10 |
| 16 | 1.3.4 | طراحی کنترل |  | 53d | 2020-02-14 A | 2020-04-06 A | 9, 10 | 100% |  | 2020-02-14 | 2020-04-06 | 53d |  | 1398/11/25 | 1399/01/18 |
| 17 | 1.3.5 | طراحی حفاظت |  | 14d | 2020-04-07 A | 2020-04-20 A | 16 | 100% |  | 2020-04-07 | 2020-04-20 | 14d |  | 1399/01/19 | 1399/02/01 |
| 18 | 1.3.6 | طراحی خنک سازی |  | 8d | 2020-02-26 A | 2020-03-04 A | 13, 14, 11 | 100% |  | 2020-02-26 | 2020-03-04 | 8d |  | 1398/12/07 | 1398/12/14 |
| 19 | 1.4 | **ماژول 120 کیلو وات** |  | 129d | 2020-02-14 A | 2020-06-21 A |  | 100% |  | 2020-02-14 | 2020-06-21 | 129d |  | 1398/11/25 | 1399/04/01 |
| 20 | 1.4.1 | تامین قطعات نمونه آزمایشگاهی |  | 4d | 2020-02-14 A | 2020-02-17 A | 13, 14, 15 | 100% |  | 2020-02-14 | 2020-02-17 | 4d |  | 1398/11/25 | 1398/11/28 |
| 21 | 1.4.2 | ساخت نمونه آزمایشگاهی |  | 15d | 2020-02-18 A | 2020-03-03 A | 20 | 100% |  | 2020-02-18 | 2020-03-03 | 15d |  | 1398/11/29 | 1398/12/13 |
| 22 | 1.4.3 | تست نمونه آزمایشگاهی |  | 110d | 2020-03-04 A | 2020-06-21 A | 21 | 100% |  | 2020-03-04 | 2020-06-21 | 110d |  | 1398/12/14 | 1399/04/01 |
| 23 | 1.5 | **ماژول 2.5 مگاوات** |  | 1188d | 2020-06-22 A | 2023-09-22 |  | 73% | 324d | 2020-06-22 | 2022-01-07 | 565d | 0d | 1399/04/02 | 1402/06/31 |
| 24 | 1.5.1 | تامین قطعات |  | 400d | 2020-06-22 A | 2022-08-12 A | 22 | 100% |  | 2020-06-22 | 2021-07-26 | 400d |  | 1399/04/02 | 1401/05/21 |
| 25 | 1.5.2 | تهیه و طراحی بردها |  | 65d | 2021-05-24 A | 2022-06-13 A | 24FS-64d | 100% |  | 2021-05-24 | 2021-07-27 | 65d |  | 1400/03/03 | 1401/03/23 |

Notes:
- 24: تهی دید ها - فعالی بحرانی

| ID | WBS | Task | Type | Duration | Start | Finish | Predecessors | Complete | Remaining | Baseline start | Baseline finish | Baseline duration | Total slack | Constraint | شروع | پایان |
| --- | --- | --- | --- | --- | --- | --- | --- | --- | --- | --- | --- | --- | --- | --- | --- | --- |
| 26 | 1.5.3 | **ساخت و مونتاژ بخش قدرت** |  | 762d | 2021-07-28 A | 2023-08-28 |  | 33% | 508d | 2021-07-28 | 2021-10-29 | 94d | 0d |  | 1400/05/06 | 1402/06/06 |
| 27 | 1.5.3.1 | مونتاژ کلی ماژول ها در تابلوی اینورتر |  | 13d | 2021-07-28 A | 2022-07-19 A | 24FS-30d | 100% |  | 2021-07-28 | 2021-08-08 | 12d |  |  | 1400/05/06 | 1401/04/28 |
| 28 | 1.5.3.2 | انجام کابل کشی،شین کشی و سیم کشی های اینورتر |  | 13d | 2022-07-19 A | 2022-08-01 A | 27 | 100% |  | 2021-08-09 | 2021-08-20 | 12d |  | start no earlier than 2022-05-24 | 1401/04/28 | 1401/05/10 |
| 29 | 1.5.3.3 | مونتاژ جداگانه ماژول های رکتیفایر |  | 13d | 2021-08-10 A | 2022-07-23 A | 28SS | 100% |  | 2021-08-09 | 2021-08-20 | 12d |  |  | 1400/05/19 | 1401/05/01 |
| 30 | 1.5.3.4 | مونتاژ کلی ماژول ها در تابلوی رکتیفایر |  | 13d | 2022-07-23 A | 2022-08-05 A | 29 | 100% |  | 2021-08-21 | 2021-09-24 | 35d |  | start no earlier than 2022-05-24 | 1401/05/01 | 1401/05/14 |
| 31 | 1.5.3.5 | انجام کابل کشی،شین کشی و سیم کشی های رکتیفایر |  | 13d | 2022-08-05 A | 2022-08-18 A | 30 | 100% |  | 2021-09-25 | 2021-10-29 | 35d |  | start no earlier than 2022-05-24 | 1401/05/14 | 1401/05/27 |
| 32 | 1.5.3.6 | تامین مالی طرح | milestone | 0d | 2023-04-21 | 2023-04-21 |  |  |  |  |  |  | 0d | start no earlier than 2023-04-21 | 1402/02/01 | 1402/02/01 |
| 33 | 1.5.3.7 | ساخت و مونتاژ بخش های مختلف ترانسفورماتور |  | 120d | 2023-04-21 | 2023-08-18 | 25, 32 |  |  | 2021-07-28 | 2021-08-31 | 35d | 0d |  | 1402/02/01 | 1402/05/27 |
| 34 | 1.5.3.8 | قرار دادن بخش های مختلف ترانسفورماتور در مخزن یا تابلو |  | 10d | 2023-08-19 | 2023-08-28 | 33 |  |  | 2021-09-01 | 2021-10-05 | 35d | 0d | start no earlier than 2022-05-24 | 1402/05/28 | 1402/06/06 |
| 35 | 1.5.4 | **ساخت و مونتاژ بخش کنترل** |  | 30d | 2022-06-13 A | 2022-07-13 A |  | 100% |  | 2021-07-28 | 2021-08-26 | 30d |  |  | 1401/03/23 | 1401/04/22 |
| 36 | 1.5.4.1 | مونتاژبردهای کنترلی |  | 20d | 2022-06-13 A | 2022-07-03 A | 25 | 100% |  | 2021-07-28 | 2021-08-16 | 20d |  | start no earlier than 2022-05-24 | 1401/03/23 | 1401/04/12 |
| 37 | 1.5.4.2 | قراردادن بردهای کنترلی در تابلو |  | 10d | 2022-07-03 A | 2022-07-13 A | 36 | 100% |  | 2021-08-17 | 2021-08-26 | 10d |  | start no earlier than 2022-05-24 | 1401/04/12 | 1401/04/22 |
| 38 | 1.5.5 | **تست کارگاهی** |  | 155d | 2023-04-21 | 2023-09-22 |  |  |  | 2021-08-27 | 2022-01-07 | 134d | 0d |  | 1402/02/01 | 1402/06/31 |
| 39 | 1.5.5.1 | فراهم کردن بستر تست مناسب |  | 30d | 2023-04-21 | 2023-05-20 | 37, 28, 31, 32 |  |  | 2021-11-29 | 2021-12-18 | 20d | 100d | start no earlier than 2022-05-24 | 1402/02/01 | 1402/02/30 |
| 40 | 1.5.5.2 | تست کل سیستم در ولتاژ نامی جریان پایین |  | 25d | 2023-08-29 | 2023-09-22 | 39, 37, 28, 31, 34 |  |  | 2021-12-19 | 2022-01-07 | 20d | 0d | start no earlier than 2022-05-24 | 1402/06/07 | 1402/06/31 |
| 41 | 1.5.5.3 | تست کل سیستم در جریان نامی ولتاژ پایین |  | 25d | 2023-08-29 | 2023-09-22 | 39, 37, 28, 31, 34 |  |  | 2021-12-19 | 2022-01-07 | 20d | 0d | start no earlier than 2022-05-24 | 1402/06/07 | 1402/06/31 |
| 42 | 1.6 | پایان | milestone | 0d | 2023-09-22 | 2023-09-22 | 41 |  |  |  |  |  | 0d |  | 1402/06/31 | 1402/06/31 |
